# CRONOGRAMA PAULISTAS-leoflavia

Schedule from MS Project, 2004-04-01 to 2006-06-01.
X

## Calendars

- Padrão: Mon-Fri 08:00-12:00, 13:00-17:00; Sat-Sun off. Exceptions (off unless hours are given): 2004-05-01 09:00-13:00, 14:00-18:00, 2004-08-01 09:00-13:00, 14:00-18:00, 2005-01-01 09:00-13:00, 14:00-18:00, 2005-05-01 09:00-13:00, 14:00-18:00, 2005-12-31 09:00-13:00, 14:00-18:00, 2006-04-01 09:00-13:00, 14:00-18:00.

## Schedule

| ID | WBS | Task | Type | Duration | Start | Finish | Baseline start | Baseline finish | Baseline duration | Total slack | Constraint |
| --- | --- | --- | --- | --- | --- | --- | --- | --- | --- | --- | --- |
| 1 | 1 | MARCOS |  | 1d | 2004-09-03 | 2004-09-06 | 2004-04-01 | 2004-04-02 | 1d | 457d |  |
| 2 | 2 | INÍCIO DA OBRA | milestone | 0d | 2004-04-01 | 2004-04-01 | 2004-04-01 | 2004-04-01 | 0d | 571d | start no earlier than 2004-04-01 |
| 3 | 3 | INÍCIO DA ESCAVAÇÃO DO TÚNEL DE ADUÇÃO | milestone | 0d | 2004-11-01 | 2004-11-01 | 2006-06-01 | 2006-06-01 | 0d | 417d | start no earlier than 2004-11-01 |
| 4 | 4 | INÍCIO DA ESCAVAÇÃO DO TÚNEL DE DESVIO | milestone | 0d | 2004-11-01 | 2004-11-01 | 2006-06-01 | 2006-06-01 | 0d | 417d | start no earlier than 2004-11-01 |
| 5 | 5 | INÍCIO DA CONCRETAGEM DO TOMADA DE DESVIO | milestone | 0d | 2005-01-01 | 2005-01-01 | 2005-01-01 | 2005-01-01 | 0d | 372.12d | start no earlier than 2005-01-01 |
| 6 | 6 | INÍCIO DA CONCRETAGEM DA CASA DE FORÇA | milestone | 0d | 2004-12-01 | 2004-12-01 | 2004-12-01 | 2004-12-01 | 0d | 395d | start no earlier than 2004-12-01 |
| 7 | 7 | INÍCIO DA MONTAGEM DA PONTE ROLANTE | milestone | 0d | 2005-07-01 | 2005-07-01 | 2005-07-01 | 2005-07-01 | 0d | 241d | start no earlier than 2005-07-01 |
| 8 | 8 | INÍCIO DE ENCHIMENTO DO RESERVATÓRIO | milestone | 0d | 2005-11-01 | 2005-11-01 | 2005-11-01 | 2005-11-01 | 0d | 154d | start no earlier than 2005-11-01 |
| 9 | 9 | INÍCIO DA GERAÇÃO COMERCIAL PRIMEIRA UNIDADE | milestone | 0d | 2006-06-01 | 2006-06-01 | 2006-06-01 | 2006-06-01 | 0d | 0d | start no earlier than 2006-06-01 |
| 10 | 10 | **CIRCUITO DE ADUÇÃO** |  | 308d | 2004-04-02 | 2005-06-01 | 2004-04-02 | 2005-06-01 | 307d | 262.12d |  |
| 11 | 10.1 | Desmatamento, destocamento e limpeza |  | 87d | 2004-04-02 | 2004-07-31 | 2004-04-02 | 2004-07-31 | 86d | 483.12d | finish no earlier than 2004-07-31 |
| 12 | 10.2 | Escavação Comum |  | 89d | 2004-06-02 | 2004-10-01 | 2004-06-01 | 2004-10-01 | 89d | 437.12d | finish no earlier than 2004-10-01 |
| 13 | 10.3 | Escavação em rocha a céu aberto |  | 44d | 2004-09-01 | 2004-11-01 | 2004-09-01 | 2004-11-01 | 44d | 416.12d | finish no earlier than 2004-11-01 |
| 14 | 10.4 | Escavação em rocha subterrânea |  | 131d | 2004-11-01 | 2005-04-30 | 2004-11-01 | 2005-04-30 | 130d | 286.12d | finish no earlier than 2005-04-30 |
| 15 | 10.5 | Limpeza e tratamento das fundações |  | 23.88d | 2004-12-01 | 2005-01-01 | 2004-12-01 | 2005-01-01 | 22.88d | 371.12d | finish no earlier than 2005-01-01 |
| 16 | 10.6 | Tratamento do túnel |  | 110d | 2005-01-01 | 2005-06-01 | 2005-01-01 | 2005-06-01 | 108d | 262.12d | finish no earlier than 2005-06-01 |
| 17 | 11 | **TOMADA D´ÁGUA** |  | 151.12d | 2005-02-02 | 2005-08-31 | 2005-02-02 | 2005-08-31 | 151.12d | 198d |  |
| 18 | 11.1 | Concretagem do primeiro estágio |  | 108d | 2005-02-02 | 2005-06-30 | 2005-02-02 | 2005-06-30 | 107d | 241.12d | finish no earlier than 2005-06-30 |
| 19 | 11.2 | Concretagem do segundo estágio / Montagem |  | 43d | 2005-07-01 | 2005-08-31 | 2005-07-01 | 2005-08-31 | 43d | 198d | start no earlier than 2005-07-01 |
| 20 | 12 | **TÚNEL DE ADUÇÃO** |  | 177d | 2005-05-01 | 2005-12-31 | 2005-05-01 | 2005-12-31 | 176d | 109.12d |  |
| 21 | 12.1 | Blindagem |  | 89d | 2005-05-01 | 2005-08-31 | 2005-05-01 | 2005-08-31 | 88d | 197.12d | finish no earlier than 2005-08-31 |
| 22 | 12.2 | Concretagem |  | 66d | 2005-08-01 | 2005-10-31 | 2005-08-01 | 2005-10-31 | 66d | 154.12d | finish no earlier than 2005-10-31 |
| 23 | 12.3 | Bifurcação |  | 44d | 2005-11-02 | 2005-12-31 | 2005-11-01 | 2005-12-31 | 44d | 109.12d | finish no earlier than 2005-12-31 |
| 24 | 13 | **CASA DE FORÇA** |  | 549d | 2004-05-01 | 2006-05-31 | 2004-05-01 | 2006-05-31 | 547d | 0.12d |  |
| 25 | 13.1 | Escavação Comum |  | 45d | 2004-05-01 | 2004-07-01 | 2004-05-01 | 2004-07-01 | 44d | 504.12d | finish no earlier than 2004-07-01 |
| 26 | 13.2 | Escavação em rocha a céu aberto |  | 87.88d | 2004-07-02 | 2004-11-01 | 2004-07-01 | 2004-11-01 | 87.88d | 416.12d | finish no earlier than 2004-11-01 |
| 27 | 13.3 | Concretagem do primeiro estágio |  | 241d | 2004-12-01 | 2005-10-31 | 2004-12-01 | 2005-10-31 | 239d | 154.12d | finish no earlier than 2005-10-31 |
| 28 | 13.4 | Viga da ponte |  | 22d | 2005-06-01 | 2005-06-30 | 2005-06-01 | 2005-06-30 | 22d | 241.12d | finish no earlier than 2005-06-30 |
| 29 | 13.5 | Montagem da ponte |  | 21d | 2005-07-01 | 2005-07-31 | 2005-07-01 | 2005-07-31 | 21d | 220.12d | finish no earlier than 2005-07-31 |
| 30 | 13.6 | Montagem tubo de sucção (incluindo a concretagem) |  | 44d | 2005-03-01 | 2005-05-01 | 2005-03-01 | 2005-05-01 | 43.88d | 286d | start no earlier than 2005-03-01 |
| 31 | 13.7 | Montagem do cone (pré distribuidor) - concretagem |  | 132d | 2005-05-01 | 2005-10-31 | 2005-05-01 | 2005-10-31 | 131d | 154.12d | finish no earlier than 2005-10-31 |
| 32 | 13.8 | Montagem da tubina / gerador |  | 129d | 2005-11-03 | 2006-04-30 | 2005-11-02 | 2006-04-30 | 128d | 23.12d | finish no earlier than 2006-04-30 |
| 33 | 13.9 | Teste e comissionamento |  | 23d | 2006-05-01 | 2006-05-31 | 2006-05-01 | 2006-05-31 | 23d | 0.12d | finish no earlier than 2006-05-31 |

| ID | WBS | Task | Duration | Start | Finish | Baseline start | Baseline finish | Baseline duration | Total slack | Constraint |
| --- | --- | --- | --- | --- | --- | --- | --- | --- | --- | --- |
| 34 | 14 | **ÁREA DE MONTAGEM** | 132d | 2004-12-01 | 2005-05-31 | 2004-12-01 | 2005-05-31 | 132d | 263.12d |  |
| 35 | 14.1 | Concretagem do primeiro estágio | 132d | 2004-12-01 | 2005-05-31 | 2004-12-01 | 2005-05-31 | 130d | 263.12d | finish no earlier than 2005-05-31 |
| 36 | 15 | **TOMADA DE DESVIO** | 87.12d | 2005-01-01 | 2005-05-02 | 2005-01-01 | 2005-05-01 | 87d | 285d |  |
| 37 | 15.1 | Concretagem do primeiro estágio | 65d | 2005-01-01 | 2005-03-31 | 2005-01-01 | 2005-03-31 | 64d | 307.12d | finish no earlier than 2005-03-31 |
| 38 | 15.2 | Concretagem do segundo estágio / Montagem | 45d | 2005-03-01 | 2005-05-02 | 2005-04-01 | 2005-05-01 | 20.88d | 285d | start no earlier than 2005-03-01 |
| 39 | 16 | **TÚNEL DE DESVIO** | 110d | 2004-11-01 | 2005-03-31 | 2004-11-01 | 2005-03-31 | 110d | 307.12d |  |
| 40 | 16.1 | Escavação / tratamento | 110d | 2004-11-01 | 2005-03-31 | 2004-11-01 | 2005-03-31 | 109d | 307.12d | finish no earlier than 2005-03-31 |
| 41 | 17 | **VERTEDOURO / CALHA** | 374d | 2004-08-01 | 2005-12-31 | 2004-06-01 | 2005-09-30 | 351d | 109.12d |  |
| 42 | 17.1 | Desmatamento, destocamento e limpeza | 45d | 2004-08-01 | 2004-09-30 | 2004-06-01 | 2004-07-31 | 44d | 438.12d | finish no earlier than 2004-09-30 |
| 43 | 17.2 | Escavação comum | 66d | 2004-10-01 | 2004-12-31 | 2004-07-01 | 2004-09-30 | 66d | 372.12d | finish no earlier than 2004-12-31 |
| 44 | 17.3 | Escavação em rocha / tratamento | 65d | 2005-01-01 | 2005-03-31 | 2004-10-01 | 2004-12-31 | 66d | 307.12d | finish no earlier than 2005-03-31 |
| 45 | 17.4 | Concretagem | 132d | 2005-04-01 | 2005-09-30 | 2005-01-01 | 2005-06-30 | 129d | 175.12d | finish no earlier than 2005-09-30 |
| 46 | 17.5 | Montagem | 65d | 2005-10-04 | 2005-12-31 | 2005-07-01 | 2005-09-30 | 66d | 109.12d | finish no earlier than 2005-12-31 |
| 47 | 18 | **ENSECADEIRAS** | 43d | 2005-02-01 | 2005-04-01 | 2004-12-01 | 2006-04-30 | 371d | 307d |  |
| 48 | 18.1 | Construção | 43d | 2005-02-01 | 2005-04-01 | 2004-12-01 | 2004-12-31 | 23d | 307d | start no earlier than 2005-02-01 |
| 49 | 19 | **BARRAGEM** | 416d | 2004-04-02 | 2005-10-31 | 2004-04-02 | 2005-10-31 | 415d | 154.12d |  |
| 50 | 19.1 | Desmatamento, destocamento e limpeza | 65d | 2004-04-02 | 2004-06-30 | 2004-04-02 | 2004-06-30 | 64d | 505.12d | finish no earlier than 2004-06-30 |
| 51 | 19.2 | Escavação comum | 95.39d | 2004-05-01 | 2005-05-03 | 2004-05-01 | 2004-07-29 | 64d | 283.86d | start no earlier than 2004-05-01 |
| 52 | 19.3 | Tratamento | 176d | 2004-06-15 | 2005-08-30 | 2004-06-14 | 2005-10-31 | 240d | 198.12d | finish no earlier than 2005-08-30 |
| 53 | 19.4 | Compactação | 239d | 2004-06-17 | 2005-10-31 | 2004-06-16 | 2005-10-31 | 239d | 154.12d | finish no earlier than 2005-10-31 |
